# MINUS_Schedule_2008_1025_feedback

Schedule from MS Project, 2008-09-04 to 2008-11-27, A marks actual dates.
Booz Allen Hamilton

## Calendars

- Standard: Mon-Fri 08:00-12:00, 13:00-17:00; Sat-Sun off.

## Schedule

| ID | WBS | Task | Type | Duration | Start | Finish | Predecessors | Complete | Remaining | Baseline start | Baseline finish | Baseline duration | Total slack | Free slack | Constraint |
| --- | --- | --- | --- | --- | --- | --- | --- | --- | --- | --- | --- | --- | --- | --- | --- |
| 1 | 1 | **MINUS Research Schedule** |  | 61d? | 2008-09-04 A | 2008-11-27 |  | 50% | 30.48d? |  |  |  | 0d |  |  |
| 2 | 1.1 | **Prepare Proposal** |  | 24d? | 2008-09-04 A | 2008-10-07 |  | 96% | 0.93d? | 2008-09-08 | 2008-09-11 | 0d? | 37d |  |  |
| 3 | 1.1.1 | Develop Project Scope |  | 5d | 2008-09-04 A | 2008-09-10 A |  | 100% |  |  |  |  |  |  | start no earlier than 2008-02-25 |
| 4 | 1.1.2 | Identify Stakeholders |  | 1.13d | 2008-09-04 A | 2008-09-11 A | 3 | 100% |  |  |  |  |  |  | finish no earlier than 2008-09-11 |
| 5 | 1.1.3 | Conduct Market Research |  | 6d | 2008-09-04 A | 2008-09-11 A | 4 | 100% |  |  |  |  |  |  | finish no earlier than 2008-09-11 |
| 6 | 1.1.4 | Identify Sponsors |  | 2d? | 2008-09-04 A | 2008-09-11 A | 5 | 100% |  |  |  |  |  |  | finish no earlier than 2008-09-11 |
| 7 | 1.1.5 | Identify Problem Statement |  | 6d? | 2008-09-04 A | 2008-09-11 A | 6 | 100% |  |  |  |  |  |  | start no earlier than 2008-09-04 |
| 8 | 1.1.6 | Identify Team Objective |  | 6d? | 2008-09-04 A | 2008-09-11 A | 7 | 100% |  |  |  |  |  |  | finish no earlier than 2008-09-11 |
| 9 | 1.1.7 | Determine Team Role |  | 6d? | 2008-09-04 A | 2008-09-11 A | 8 | 100% |  |  |  |  |  |  | finish no earlier than 2008-09-11 |
| 10 | 1.1.8 | Identify Mission, Values, and Goals |  | 2d? | 2008-09-10 A | 2008-09-12 | 9 | 50% | 1d? |  |  |  | 54d |  | finish no earlier than 2008-09-11 |
| 11 | 1.1.9 | **Lifecycle and System Architecture** |  | 4d? | 2008-09-04 A | 2008-09-09 A | 10 | 100% |  |  |  |  |  |  |  |
| 12 | 1.1.9.1 | Identify project development process and Architecture |  | 3d | 2008-09-04 A | 2008-09-08 A | 10 | 100% |  |  |  |  |  |  | start no earlier than 2008-09-04 |
| 13 | 1.1.9.2 | Document Project Process and Architecture | milestone | 1d? | 2008-09-09 A | 2008-09-09 A | 12 | 100% |  |  |  |  |  |  |  |
| 14 | 1.1.10 | **Stakeholder Identification** |  | 9d? | 2008-09-04 A | 2008-09-16 A | 4, 5, 6 | 100% |  |  |  |  |  |  |  |
| 15 | 1.1.10.1 | Identify Stakeholder Needs |  | 6d? | 2008-09-04 A | 2008-09-11 A | 4 | 100% |  |  |  |  |  |  | finish no earlier than 2008-09-11 |
| 16 | 1.1.10.2 | Create Stakeholder Value Mapping |  | 2d | 2008-09-12 A | 2008-09-15 A | 15 | 100% |  |  |  |  |  |  |  |
| 17 | 1.1.10.3 | Create QFD |  | 2d | 2008-09-15 A | 2008-09-16 A | 16 | 100% |  |  |  |  |  |  |  |
| 18 | 1.1.11 | **Functional Decomposition** |  | 7d? | 2008-09-10 A | 2008-09-18 | 17 | 82% | 1.27d? |  |  |  | 50d |  |  |
| 19 | 1.1.11.1 | Develop Functional Decomposition |  | 5d | 2008-09-10 A | 2008-09-16 A | 17 | 100% |  |  |  |  |  |  |  |
| 20 | 1.1.11.2 | Intent Specification |  | 4d? | 2008-09-10 A | 2008-09-15 A | 19 | 100% |  |  |  |  |  |  | finish no earlier than 2008-09-15 |
| 21 | 1.1.11.3 | Develop Alternate form functions to determine system architecture |  | 1d? | 2008-09-17 | 2008-09-17 | 20 |  |  |  |  |  | 43.5d | 0d |  |
| 22 | 1.1.11.4 | Select best form function |  | 1d? | 2008-09-18 | 2008-09-18 | 21 |  |  |  |  |  | 50d |  |  |
| 23 | 1.1.12 | **Concept Development** |  | 18d | 2008-09-12 A | 2008-10-07 A | 21 | 100% |  |  |  |  |  |  |  |
| 24 | 1.1.12.1 | Draft System level CONOPS |  | 10d | 2008-09-12 A | 2008-09-25 A | 17 | 100% |  |  |  |  |  |  |  |
| 25 | 1.1.12.2 | Finalize CONOPS | milestone | 8d | 2008-09-26 A | 2008-10-07 A | 24 | 100% |  |  |  |  |  |  |  |

| ID | WBS | Task | Type | Duration | Start | Finish | Predecessors | Complete | Remaining | Total slack | Free slack |
| --- | --- | --- | --- | --- | --- | --- | --- | --- | --- | --- | --- |
| 26 | 1.2 | **System Requirements** |  | 35d? | 2008-09-12 A | 2008-10-30 | 21 | 79% | 7.5d? | 20d |  |
| 27 | 1.2.1 | Define Problem |  | 2d | 2008-09-12 A | 2008-09-15 A | 21 | 100% |  |  |  |
| 28 | 1.2.2 | Identify Detailed System Objectives |  | 5d | 2008-09-16 A | 2008-09-22 A | 27 | 100% |  |  |  |
| 29 | 1.2.3 | Define Functions and Behavior of the System |  | 5d | 2008-09-23 A | 2008-09-29 | 28 | 75% | 1.25d | 12.9d | 0d |
| 30 | 1.2.4 | Develop System Requirements Document |  | 17d | 2008-09-30 A | 2008-10-22 | 29 | 75% | 4.25d | 26d |  |
| 31 | 1.2.5 | Determine critical ilities of the system |  | 1d? | 2008-10-23 A | 2008-10-23 A | 30 | 100% |  |  |  |
| 32 | 1.2.6 | Finalize System Requirements Document | milestone | 5d | 2008-10-24 A | 2008-10-30 | 31 | 60% | 2d | 20d |  |
| 33 | 1.3 | **System Design Specification** |  | 35d? | 2008-09-30 A | 2008-11-17 | 29 | 14% | 30.1d? | 8d |  |
| 34 | 1.3.1 | Develop Use Cases |  | 3d | 2008-09-30 A | 2008-10-02 A | 29 | 100% |  |  |  |
| 35 | 1.3.2 | Identify Hardware/Software Alternatives |  | 8d | 2008-10-03 A | 2008-10-14 | 34 | 50% | 4d | 0d |  |
| 36 | 1.3.3 | Cost Analysis |  | 5d | 2008-10-15 | 2008-10-21 | 35 |  |  | 0d |  |
| 37 | 1.3.4 | Determine Hardware/Software Components |  | 4d | 2008-10-22 | 2008-10-27 | 36 |  |  | 0d |  |
| 38 | 1.3.5 | Develop System Design Specification |  | 14d | 2008-10-28 | 2008-11-14 | 37 |  |  | 15d | 0d |
| 39 | 1.3.6 | Finalize System Design Specification | milestone | 1d | 2008-11-17 | 2008-11-17 | 38 |  |  | 15d |  |
| 40 | 1.3.7 | **Architecture Development** |  | 15d? | 2008-10-08 | 2008-10-28 | 23 |  |  | 22d |  |
| 41 | 1.3.7.1 | Develop Operational View (OV-1: High Level Operational Concept Graphic) |  | 4d | 2008-10-08 | 2008-10-13 | 23 |  |  | 29d | 0d |
| 42 | 1.3.7.2 | Develop Technical View (TV-1: Technical Architecture Profile) |  | 5d | 2008-10-14 | 2008-10-20 | 41 |  |  | 29d | 0d |
| 43 | 1.3.7.3 | Develop Systems View (SV-1: System Interface Description) |  | 5d | 2008-10-21 | 2008-10-27 | 42 |  |  | 29d | 0d |
| 44 | 1.3.7.4 | Finalize Architecture Views | milestone | 1d? | 2008-10-28 | 2008-10-28 | 43 |  |  | 29d |  |
| 45 | 1.4 | **Business Case Development** |  | 17d | 2008-10-28 | 2008-11-19 | 37 |  |  | 0d |  |
| 46 | 1.4.1 | Determine Technology Strategy |  | 5d | 2008-10-28 | 2008-11-03 | 37 |  |  | 25d |  |
| 47 | 1.4.2 | Cash flow baseline development |  | 9d | 2008-10-28 | 2008-11-07 | 37 |  |  | 21d |  |
| 48 | 1.4.3 | Conduct Sensitivity Analysis |  | 11d | 2008-10-28 | 2008-11-11 | 37 |  |  | 19d |  |
| 49 | 1.4.4 | Conduct Risk Analysis |  | 10d | 2008-10-28 | 2008-11-10 | 37 |  |  | 0d |  |
| 50 | 1.4.5 | Develop Market Introduction Strategy |  | 4d | 2008-10-28 | 2008-10-31 | 37 |  |  | 3d | 0d |
| 51 | 1.4.6 | Decision Tree Model |  | 3d | 2008-11-03 | 2008-11-05 | 50 |  |  | 3d |  |
| 52 | 1.4.7 | Finalize Business Case | milestone | 7d | 2008-11-11 | 2008-11-19 | 37, 49, 50, 51 |  |  | 0d |  |

| ID | WBS | Task | Type | Duration | Start | Finish | Predecessors | Total slack |
| --- | --- | --- | --- | --- | --- | --- | --- | --- |
| 53 | 1.5 | **Project Report** |  | 6d | 2008-11-20 | 2008-11-27 | 52 | 0d |
| 54 | 1.5.1 | Consolidate deliverables into a single report |  | 1d | 2008-11-20 | 2008-11-20 | 52 | 0d |
| 55 | 1.5.2 | Finalize Report | milestone | 5d | 2008-11-21 | 2008-11-27 | 54 | 0d |
